# Sequoia HR ASY

Schedule from MS Project, 2006-08-25 to 2008-01-07, A marks actual dates.
Windsor Machine Products Inc

## Calendars

- Standard: Mon-Fri 08:00-12:00, 13:00-17:00; Sat-Sun off.

## Schedule

| ID | Task | Duration | Start | Finish | Predecessors | Complete | Remaining | Baseline start | Baseline finish | Baseline duration | Total slack | Free slack | Constraint |
| --- | --- | --- | --- | --- | --- | --- | --- | --- | --- | --- | --- | --- | --- |
| 1 | Internal Tools | 55d | 2006-09-25 | 2006-12-08 |  |  |  |  |  |  | 281d |  | finish no earlier than 2006-12-08 |
| 2 | Hydraulic Form Tools- 71943-X7C00-A- Upper Tube form, Insert | 43d | 2006-09-25 A | 2006-11-22 A |  | 100% |  |  |  |  |  |  | finish no earlier than 2006-11-22 |
| 3 | Broach Cutting Tools - 71941-X7C01 & 71941-X7C00-A - Tube Post Stay | 43d | 2006-09-25 A | 2006-11-22 A |  | 100% |  |  |  |  |  |  | finish no earlier than 2006-11-22 |
| 4 | Broach Work holding tools -71941-X7C01 & 71941-X7C00-A - Tube Post Stay | 45d | 2006-09-25 A | 2006-11-24 A |  | 100% |  |  |  |  |  |  | start no earlier than 2006-09-25 |
| 5 | Tube Post Slotting Machine-(cable Attachment point) 71941-X7C00-A - Tube Post Stay | 45d | 2006-09-25 A | 2006-11-24 A |  | 100% |  |  |  |  |  |  | start no earlier than 2006-09-25 |
| 6 | Check Fixture- 71941-X7C00-A - Tube Post Stay | 15d | 2006-11-13 A | 2006-12-01 A |  | 100% |  |  |  |  |  |  | start no earlier than 2006-11-13 |
| 7 | Weld Fixture - Final Asm 71907-0C020 & 30 & 50 | 45d | 2006-09-25 A | 2006-11-24 A |  | 100% |  |  |  |  |  |  | start no earlier than 2006-09-25 |
| 8 | Additional Weld Fixtures for Production and Modify current one | 20d | 2006-11-13 A | 2006-12-08 |  | 40% | 12d |  |  |  | 281d |  | start no earlier than 2006-11-13 |
| 9 | Check Fixture- Final Weld ASM-71907-0C020 & 30 & 50 | 15d | 2006-11-13 A | 2006-12-01 A |  | 100% |  |  |  |  |  |  | start no earlier than 2006-09-25 |
| 10 | Weld Fixture- Tube Post to small side stamping | 45d | 2006-09-25 A | 2006-11-24 A |  | 100% |  |  |  |  |  |  | start no earlier than 2006-09-25 |
| 11 | Additional Weld Fixtures for Production -On hold until we recieve authorization to proceed with changes on ECI#383WAF0150 | 20d | 2006-11-13 A | 2006-12-08 |  | 45% | 11d |  |  |  | 281d |  | start no earlier than 2006-11-13 |
| 12 | Check Fixture- tube to side stamping - 71907-0C020 & 30 & 50 | 15d | 2006-11-13 A | 2006-12-01 A |  | 100% |  |  |  |  |  |  | start no earlier than 2006-11-13 |
| 13 | Weld Fixture- Tube Post to Main Stamping | 20d | 2006-10-25 A | 2006-11-21 A |  | 100% |  |  |  |  |  |  | start no earlier than 2006-10-25 |
| 14 | Additional Weld Fixtures for Production~ On hold until we recieve authorization to proceed with changes on ECI#383WAF0150 | 20d | 2006-11-13 A | 2006-12-08 |  | 45% | 11d |  |  |  | 281d |  | start no earlier than 2006-11-13 |
| 15 | Check Fixture- tube to main stamping - 71907-0C020 & 30 & 50 | 15d | 2006-11-08 A | 2006-11-28 A |  | 100% |  |  |  |  |  |  | start no earlier than 2006-09-25 |
| 16 | Weld Fixture- Shaft to 3 side stampings POWER Only 71907-0C030 & 50 | 45d | 2006-09-25 A | 2006-11-24 A |  | 100% |  |  |  |  |  |  | start no earlier than 2006-09-25 |
| 17 | Additional Weld Fixtures for Production~ On hold until we recieve authorization to proceed with changes on ECI#383WAF0150 | 15d | 2006-11-13 A | 2006-12-01 |  | 45% | 8.25d |  |  |  | 286d |  | start no earlier than 2006-11-13 |
| 18 | Check Fixture- Shaft to 3 side stampings stamping - 71907-0C030 & 50 | 15d | 2006-11-13 A | 2006-12-01 A |  | 100% |  |  |  |  |  |  | start no earlier than 2006-11-13 |
| 19 | Final Assembly Checking fixture | 20d | 2006-10-31 A | 2006-11-27 A |  | 100% |  |  |  |  |  |  | start no earlier than 2006-10-31 |
| 20 | 1st Foam Mold- Pad Front- 71953-XC00-A | 22d | 2006-08-25 A | 2006-09-25 A |  | 100% |  |  |  |  |  |  | start no earlier than 2006-09-25 |
| 21 | 2-3 Foam Molds- Pad Front- 71953-XC00-A | 55d | 2006-09-25 A | 2006-12-08 A |  | 100% |  |  |  |  |  |  | start no earlier than 2006-09-25 |
| 22 | 1st Foam Mold- Pad Rear- 71953-XC01-A | 22d | 2006-08-25 A | 2006-09-25 A |  | 100% |  |  |  |  |  |  | start no earlier than 2006-08-25 |
| 23 | 2-3 Foam Molds- Pad Rear- 71953-XC01-A | 55d | 2006-09-25 A | 2006-12-08 A |  | 100% |  |  |  |  |  |  | start no earlier than 2006-09-25 |
| 24 | Vendor PPAP | 50d | 2006-09-25 A | 2006-12-01 A |  | 100% |  |  |  |  |  |  | finish no earlier than 2006-12-01 |
| 25 | 71959-X7C00-C_Holder Marwood | 50d | 2006-09-25 A | 2006-12-01 A |  | 100% |  | 1998-07-31 | 1998-07-31 | 1d |  |  | finish no earlier than 2006-12-01 |
| 26 | 71971-X7C00-B_Bracket Marwood | 50d | 2006-09-25 A | 2006-12-01 A |  | 100% |  | 1996-12-06 | 1996-12-06 | 1d |  |  | finish no earlier than 2006-12-01 |
| 27 | 71972-X7C00-B_Bracket Marwood | 50d | 2006-09-25 A | 2006-12-01 A |  | 100% |  |  |  |  |  |  | finish no earlier than 2006-12-01 |
| 28 | 71971-X7C01-A_Bracket Marwood | 50d | 2006-09-25 A | 2006-12-01 A |  | 100% |  |  |  |  |  |  | finish no earlier than 2006-12-01 |
| 29 | 72989-X7C00-B_Plate Marwood | 50d | 2006-09-25 A | 2006-12-01 A |  | 100% |  |  |  |  |  |  | finish no earlier than 2006-12-01 |
| 30 | 71945-X7C00-A_Plate GFM | 50d | 2006-09-25 A | 2006-12-01 A |  | 100% |  |  |  |  |  |  | finish no earlier than 2006-12-01 |
| 31 | 71949-X7C00-A _Hook GFM | 50d | 2006-09-25 A | 2006-12-01 A |  | 100% |  |  |  |  |  |  | finish no earlier than 2006-12-01 |
| 32 | 71983-X7C00-A_ Guide GFM | 50d | 2006-09-25 A | 2006-12-01 A |  | 100% |  |  |  |  |  |  | finish no earlier than 2006-12-01 |
| 33 | 74917-X7C00-A_Stopper GFM | 50d | 2006-09-25 A | 2006-12-01 A |  | 100% |  |  |  |  |  |  | finish no earlier than 2006-12-01 |
| 34 | 71987-X7C000-A_ Cable Hilex | 47d | 2006-09-25 A | 2006-11-28 A |  | 100% |  |  |  |  |  |  | finish no earlier than 2006-11-28 |
| 35 | 71987-X7C001_ Cable Hilex | 47d | 2006-09-25 A | 2006-11-28 A |  | 100% |  |  |  |  |  |  | finish no earlier than 2006-11-28 |
| 36 | 71463-X7C000_Spring Springs & Things | 45d | 2006-09-25 A | 2006-11-24 A |  | 100% |  |  |  |  |  |  | start no earlier than 2006-09-25 |
| 37 | 79298-X7C001-A _Spring Springs & Things | 45d | 2006-09-25 A | 2006-11-24 A |  | 100% |  |  |  |  |  |  | start no earlier than 2006-09-25 |
| 38 | 71331-X7C00-A_ Pivot Pin FORMNET | 45d | 2006-09-25 A | 2006-11-24 A |  | 100% |  |  |  |  |  |  | start no earlier than 2006-09-25 |
| 39 | 71331-X7C00-A_ Bolt FORMNET | 45d | 2006-09-25 A | 2006-11-24 A |  | 100% |  |  |  |  |  |  | start no earlier than 2006-09-25 |
| 40 | 71977-X7C00-B_ Shaft ALFA | 45d | 2006-09-25 A | 2006-11-24 A |  | 100% |  |  |  |  |  |  | start no earlier than 2006-09-25 |
| 41 | 71979-X7C00 _ Shaft ALFA | 45d | 2006-09-25 A | 2006-11-24 A |  | 100% |  |  |  |  |  |  | start no earlier than 2006-09-25 |
| 42 | 71367-X7C00-A_Link EXPRESS MOLDING | 50d | 2006-09-25 A | 2006-12-01 A |  | 100% |  |  |  |  |  |  | finish no earlier than 2006-12-01 |
| 43 | 71944-X7C00-A_FRT CVR & 71944-X7C01-A_Rear CVR EXPRESS MOLDING | 50d | 2006-09-25 A | 2006-12-01 A |  | 100% |  |  |  |  |  |  | finish no earlier than 2006-12-01 |
| 44 | 89978-X7C02_Washer Off shelf item | 15d | 2006-11-13 | 2006-12-01 |  |  |  |  |  |  | 286d |  | start no earlier than 2006-11-13 |
| 45 | 90206-10009 _Wave Washer Off shelf item | 15d | 2006-11-13 | 2006-12-01 |  |  |  |  |  |  | 286d |  | start no earlier than 2006-11-13 |
| 46 | 96160-00500_RING, SHAFT SNAP Off shelf item | 15d | 2006-11-13 | 2006-12-01 |  |  |  |  |  |  | 286d |  | start no earlier than 2006-11-13 |
| 47 | 79939-60030_ Pin Off shelf item | 15d | 2006-11-13 | 2006-12-01 |  |  |  |  |  |  | 286d |  | start no earlier than 2006-11-13 |
| 48 | 90179-06208_ Nut Off shelf item | 15d | 2006-11-13 | 2006-12-01 |  |  |  |  |  |  | 286d |  | start no earlier than 2006-11-13 |
| 49 | CV Build | 1d | 2006-12-04 A | 2006-12-04 A | 43, 10, 12, 13, 15, 16, 18, 19, 20, 22, 25, 26, 27, 28, 29, 30, 31, 32, 33, 34, 35, 36, 37, 38, 39, 40, 41, 42, 44, 45, 46, 47, 48, 2, 3, 4, 5, 6, 7, 9 | 100% |  |  |  |  |  |  |  |
| 50 | CHANGES ECI# 383WAF0150 | 8w | 2007-01-22 | 2007-03-16 |  |  |  |  |  |  | 211d |  | start no earlier than 2007-01-22 |
| 51 | 71953-XC00-B New foam tools for the front pad | 6w | 2007-01-22 | 2007-03-02 |  |  |  |  |  |  | 211d | 0d | start no earlier than 2007-01-22 |
| 52 | 71953-XC01- B New foam tools for the rear pad | 6w | 2007-01-22 | 2007-03-02 |  |  |  |  |  |  | 211d | 0d | start no earlier than 2007-01-22 |
| 53 | Modify Foam contour checking fixture | 4w | 2007-01-22 | 2007-02-16 |  |  |  |  |  |  | 221d | 10d | start no earlier than 2007-01-22 |
| 54 | 71979-X7C00-A ECI# 383WPC0176 New cutting tools for the gear shaft | 4w | 2007-01-03 | 2007-01-30 |  |  |  |  |  |  | 234d | 23d | start no earlier than 2007-01-03 |
| 55 | Modify all weld fixtures | 5w | 2007-01-22 | 2007-02-23 |  |  |  |  |  |  | 216d | 5d | start no earlier than 2007-01-22 |
| 56 | Modify all checking fixtures | 4w | 2007-01-22 | 2007-02-16 |  |  |  |  |  |  | 221d | 10d | start no earlier than 2007-01-22 |
| 57 | Develop tools, build and ship parts | 2w | 2007-03-05 | 2007-03-16 | 51, 52, 53, 54, 55, 56 |  |  |  |  |  | 211d |  |  |
| 58 | PPAP to Customer | 1d | 2007-03-19 | 2007-03-19 |  |  |  |  |  |  | 210d |  | start no earlier than 2007-03-19 |
| 59 | Production Ramp up | 1d | 2007-09-10 | 2007-09-10 |  |  |  | 1998-05-19 | 1998-06-01 | 10d | 85d |  | start no earlier than 2007-09-10 |
| 60 | Run @ Rate PTR | 1d | 2007-08-06 | 2007-08-06 |  |  |  | 1998-05-19 | 1998-06-01 | 10d | 110d |  | finish no earlier than 2007-08-06 |
| 61 | Quality Confirmation Build | 1d | 2007-11-07 | 2007-11-07 |  |  |  | 1998-05-19 | 1998-06-01 | 10d | 43d |  | start no earlier than 2007-11-07 |
| 62 | Start of Production | 1d | 2007-11-30 | 2007-11-30 |  |  |  | 1998-05-19 | 1998-05-19 | 1d | 26d |  | start no earlier than 2007-11-30 |
| 63 | Post Launch Follow-up | 1d | 2008-01-07 | 2008-01-07 |  |  |  | 1998-05-19 | 1998-06-01 | 10d | 0d |  | start no earlier than 2008-01-07 |

Notes:
- 8: On hold until we recieve authorization to proceed with changes on ECI#383WAF0150
- 11: On hold until we recieve authorization to proceed with changes on ECI#383WAF0150
- 14: On hold until we recieve authorization to proceed with changes on ECI#383WAF0150
- 17: On hold until we recieve authorization to proceed with changes on ECI#383WAF0150
- 44: We have not been able to get a production supplier to quote any fasteners. / Even with the request from TMI Purchasing to TMI fasteners supplier / We are reqesting again futher help from TMI.
- 45: We have not been able to get a production supplier to quote any fasteners. / Even with the request from TMI Purchasing to TMI fasteners supplier / We are reqesting again futher help from TMI.
- 46: We have not been able to get a production supplier to quote any fasteners. / Even with the request from TMI Purchasing to TMI fasteners supplier / We are reqesting again futher help from TMI.
- 47: We have not been able to get a production supplier to quote any fasteners. / Even with the request from TMI Purchasing to TMI fasteners supplier / We are reqesting again futher help from TMI.
- 48: We have not been able to get a production supplier to quote any fasteners. / Even with the request from TMI Purchasing to TMI fasteners supplier / We are reqesting again futher help from TMI.
